# cronograma rev2

Schedule from MS Project, 2016-05-02 to 2018-10-18, costs in .

## Calendars

- carretera Moquegua - Omate: Mon-Sun 07:00-12:00, 13:00-16:00.

## Schedule

| ID | WBS | Task | Duration | Start | Finish | Predecessors | Total slack | Free slack | Constraint | Cost |
| --- | --- | --- | --- | --- | --- | --- | --- | --- | --- | --- |
| 1 | 1 | **CARRETERA MOQUEGUA - OMATE** | 900d | 2016-05-02 | 2018-10-18 |  | -295d | 0d |  | 288,092,826.57 |
| 2 | 1.1 | **100 Obras Preliminares** | 605d | 2016-05-02 | 2017-12-27 |  |  |  |  | 6,047,926.16 |
| 3 | 1.1.1 | movilizacion y desmovilizacion de equipos | 10d | 2016-05-02 | 2016-05-11 |  | -295d | 0d | start no earlier than 2016-05-02 | 4,391,073.14 |
| 4 | 1.1.2 | topografia y georeferenciacion | 60d | 2016-05-05 | 2016-07-03 |  | 26d | 0d | start no earlier than 2016-05-05 | 203,879.56 |
| 5 | 1.1.3 | mantenimiento de transito temporal y seguridad vial | 890d | 2016-05-12 | 2018-10-18 | 3 | -295d | 0d |  | 1,071,650.11 |
| 6 | 1.1.4 | acceso a canteras, fuentes de agua, zona de procesos y dme | 7d | 2016-07-04 | 2016-07-10 | 4 | 535d | 0d |  | 381,323.35 |
| 7 | 1.2 | **200 Movimiento de tierras** | 550d | 2016-05-12 | 2017-11-12 |  | 0d |  |  | 25,379,576.95 |
| 8 | 1.2.1 | desbroce y limpieza en zonas no boscosas | 25d | 2016-07-11 | 2016-08-04 | 6 | 787d | 0d |  | 87,245.62 |
| 9 | 1.2.2 | excavacion en roca fija | 235d | 2016-05-12 | 2017-01-01 | 3 | 0d |  |  | 3,545,022.56 |
| 10 | 1.2.3 | excavacion en roca fracturada (suelta) | 160d | 2017-01-02 | 2017-06-10 | 9 | 445d | 0d |  | 5,250,949.26 |
| 11 | 1.2.4 | excavacion en material suelto | 201d | 2017-01-02 | 2017-07-21 | 9 | 297d | 0d |  | 3,155,143.46 |
| 12 | 1.2.5 | remocion de derrumbes | 50d | 2017-06-11 | 2017-07-30 | 10 | 445d |  |  | 146,718.22 |
| 13 | 1.2.6 | terraplenes con material de cantera | 140d | 2017-03-28 | 2017-08-14 | 14 | 0d |  |  | 2,647,510.6 |
| 14 | 1.2.7 | mejoramiento de suelos con material de cantera | 85d | 2017-01-02 | 2017-03-27 | 9 | 0d |  |  | 1,739,639.65 |
| 15 | 1.2.8 | perfilado y compactado de subrasantes en zonas de corte | 90d | 2017-08-15 | 2017-11-12 | 13 | 0d |  |  | 3,505,306.58 |
| 16 | 1.2.9 | banquetas de relleno | 15d | 2017-08-15 | 2017-08-29 | 13 | 38d | 0d |  | 260,694.46 |
| 17 | 1.2.10 | material de cantera para rellenos | 140d | 2017-04-12 | 2017-08-29 | 16FF | 38d | 0d |  | 5,041,346.54 |
| 18 | 1.3 | **400 Pavimentos** | 265d | 2017-11-13 | 2018-08-04 |  | 0d |  |  | 60,381,335.64 |
| 19 | 1.3.1 | **capas anticontaminantes, subbase y base** | 220d | 2017-11-13 | 2018-06-20 |  | 0d |  |  | 25,374,124.51 |
| 20 | 1.3.1.1 | base granular e=0.275 | 220d | 2017-11-13 | 2018-06-20 | 15 | 0d |  |  | 25,374,124.51 |
| 21 | 1.3.2 | **pavimentos flexibles** | 255d | 2017-11-23 | 2018-08-04 |  | 0d |  |  | 35,007,211.13 |
| 22 | 1.3.2.1 | imprimacion asfaltica | 220d | 2017-11-23 | 2018-06-30 | 20SS+10d | 0d |  |  | 808,708.08 |
| 23 | 1.3.2.2 | pavimento de concreto asfaltico caliente (mac) | 255d | 2017-11-23 | 2018-08-04 | 22SS | 0d |  |  | 12,318,995.45 |
| 24 | 1.3.2.3 | cemento asfaltico de penetracion 85/100 | 255d | 2017-11-23 | 2018-08-04 | 23SS | 55d | 0d |  | 16,449,480.38 |
| 25 | 1.3.2.4 | asfalto diluido mc-30 | 255d | 2017-11-23 | 2018-08-04 | 23SS | 55d | 0d |  | 2,138,939.19 |
| 26 | 1.3.2.5 | filler | 255d | 2017-11-23 | 2018-08-04 | 23SS | 55d | 0d |  | 2,465,038.08 |
| 27 | 1.3.2.6 | mejorador de adherencia | 255d | 2017-11-23 | 2018-08-04 | 23SS | 55d | 0d |  | 826,049.95 |

| ID | WBS | Task | Duration | Start | Finish | Predecessors | Total slack | Free slack | Cost |
| --- | --- | --- | --- | --- | --- | --- | --- | --- | --- |
| 28 | 1.4 | **500 Obras de arte y drenaje** | 751d | 2016-07-04 | 2018-07-24 |  | 86d |  | 75,121,228.92 |
| 29 | 1.4.1 | demolicion de estructuras | 29d | 2016-07-04 | 2016-08-01 | 4 | 420d | 0d | 90,247.08 |
| 30 | 1.4.2 | limpieza de cauce de rio | 9d | 2016-08-05 | 2016-08-13 | 8 | 787d | 179d | 67,935.65 |
| 31 | 1.4.3 | excavacion no clasificada para estructuras | 101d | 2016-08-02 | 2016-11-10 | 29 | 420d | 0d | 5,218,871.24 |
| 32 | 1.4.4 | relleno para estructuras | 98d | 2017-04-18 | 2017-07-24 | 36, 37FS-150d, 38, 33, 48 | 451d |  | 8,072,010.32 |
| 33 | 1.4.5 | filtro drenante | 69d | 2016-11-21 | 2017-01-28 | 59, 47SS | 530d | 79d | 2,519,670.64 |
| 34 | 1.4.6 | concreto clase h (f'c = 100 kg/cm2) | 24d | 2016-09-22 | 2016-10-15 | 31FS-50d | 563d | 0d | 550,817 |
| 35 | 1.4.7 | concreto clase g (f'c = 140 kg/cm2 + 30% pm) | 144d | 2016-08-13 | 2017-01-03 | 31FS-90d | 420d | 0d | 4,431,098.28 |
| 36 | 1.4.8 | concreto clase e (f'c = 175 kg/cm2) | 71d | 2016-11-23 | 2017-02-01 | 45FS-70d | 526d | 0d | 931,009.55 |
| 37 | 1.4.9 | concreto clase d (f'c = 210kg/cm2) | 171d | 2017-03-07 | 2017-08-24 | 40FS-120d, 46, 60 | 420d | 21d | 12,244,272.36 |
| 38 | 1.4.10 | concreto clase c (f´c = 280 kg/cm2 ) | 32d | 2017-03-17 | 2017-04-17 | 41, 61 | 451d | 0d | 494,886.14 |
| 39 | 1.4.11 | encofrado y desencofrado | 197d | 2016-08-15 | 2017-02-27 | 45FS-170d | 420d | 0d | 8,139,652.61 |
| 40 | 1.4.12 | acero de refuerzo fy=4200 kg/cm2 | 139d | 2016-09-26 | 2017-02-11 | 34FS-20d | 563d | 143d | 7,580,018.74 |
| 41 | 1.4.13 | dowells | 17d | 2017-02-28 | 2017-03-16 | 39 | 451d | 0d | 42,247.38 |
| 42 | 1.4.14 | tuberia corrugada de acero galvanizado de d=36" | 42d | 2016-11-05 | 2016-12-16 | 35FS-60d | 420d | 0d | 1,434,919.94 |
| 43 | 1.4.15 | tuberia corrugada de acero galvanizado de d=48" | 22d | 2016-12-17 | 2017-01-07 | 42 | 420d | 0d | 334,167.15 |
| 44 | 1.4.16 | tuberia corrugada de acero galvanizado de d=60" | 19d | 2017-01-08 | 2017-01-26 | 43 | 420d | 0d | 167,511.44 |
| 45 | 1.4.17 | tuberia corrugada de acero galvanizado de d=72" | 5d | 2017-01-27 | 2017-01-31 | 44 | 420d | 0d | 63,292.19 |
| 46 | 1.4.18 | tubo de pvc sap clase 10, d=3" | 27d | 2017-02-08 | 2017-03-06 | 39FS-20d | 420d | 0d | 59,261.39 |
| 47 | 1.4.19 | tubo de pvc sap clase 10, d=6" perforado | 50d | 2016-10-22 | 2016-12-10 | 59FS-30d | 560d | 0d | 1,169,159.03 |
| 48 | 1.4.20 | tubo de pvc sap clase 10, d=6" | 3d | 2016-12-11 | 2016-12-13 | 47 | 576d | 125d | 7,189.6 |
| 49 | 1.4.21 | cunetas triangular | 111d | 2017-12-03 | 2018-03-23 | 20FS-200d | 86d | 0d | 11,428,983.42 |
| 50 | 1.4.22 | cunetas rectangulares | 67d | 2018-03-24 | 2018-05-29 | 49 | 86d | 0d | 5,552,997.89 |
| 51 | 1.4.23 | cunetas de banquetas | 56d | 2018-05-30 | 2018-07-24 | 50 | 86d |  | 208,599 |
| 52 | 1.4.24 | gavion caja tipo a | 25d | 2016-11-11 | 2016-12-05 | 31 | 608d | 0d | 453,144.7 |
| 53 | 1.4.25 | gavion caja tipo b | 47d | 2016-12-06 | 2017-01-21 | 52 | 608d | 0d | 1,000,781.93 |
| 54 | 1.4.26 | gavion caja tipo c | 18d | 2017-01-22 | 2017-02-08 | 53 | 608d | 0d | 345,903.21 |
| 55 | 1.4.27 | gavion caja tipo cfa | 26d | 2016-12-06 | 2016-12-31 | 52 | 632d | 21d | 429,277.7 |
| 56 | 1.4.28 | gavion caja tipo cfb | 15d | 2017-01-22 | 2017-02-05 | 53, 55 | 611d | 3d | 312,461.33 |
| 57 | 1.4.29 | enrocado | 9d | 2017-02-09 | 2017-02-17 | 54, 56, 30 | 608d |  | 186,908.52 |
| 58 | 1.4.30 | emboquillado de piedra | 47d | 2017-02-02 | 2017-03-20 | 36 | 577d |  | 717,343.81 |
| 59 | 1.4.31 | geotextil no tejido clase 2 | 45d | 2016-10-07 | 2016-11-20 | 31FS-35d | 530d | 0d | 471,971.36 |
| 60 | 1.4.32 | junta para muro | 27d | 2016-11-20 | 2016-12-16 | 39FS-100d | 500d | 80d | 319,268.71 |
| 61 | 1.4.33 | junta en badenes | 13d | 2017-02-28 | 2017-03-12 | 39 | 455d | 4d | 71,004.41 |
| 62 | 1.4.34 | nivelacion de buzones | 10d | 2016-08-02 | 2016-08-11 | 29, 4 | 798d |  | 4,345.2 |

| ID | WBS | Task | Duration | Start | Finish | Predecessors | Total slack | Free slack | Cost |
| --- | --- | --- | --- | --- | --- | --- | --- | --- | --- |
| 63 | 1.5 | **700 Transportes** | 617d | 2017-01-02 | 2018-09-10 |  | 38d |  | 96,503,993.26 |
| 64 | 1.5.1 | transporte de materiales granulares para distancias entre 120m y 1000m | 437d | 2017-07-01 | 2018-09-10 | 17FS-60d | 38d | 0d | 4,686,911.87 |
| 65 | 1.5.2 | transporte de materiales granulares para distancias mayores de 1000m | 437d | 2017-07-01 | 2018-09-10 | 64SS | 38d |  | 48,708,837.58 |
| 66 | 1.5.3 | transporte de materiales excedentes para distancias entre 120 m y 1000 m | 358d | 2017-01-02 | 2017-12-25 | 9SS, 11SS | 297d | 0d | 11,307,359.97 |
| 67 | 1.5.4 | transporte de materiales excedentes para distancias mayores de 1000m | 358d | 2017-01-02 | 2017-12-25 | 66SS | 297d |  | 27,653,124.08 |
| 68 | 1.5.5 | transporte de mezclas asfalticas para distancias hasta 1000 m | 127d | 2017-11-23 | 2018-03-29 | 23SS | 203d | 0d | 669,756.46 |
| 69 | 1.5.6 | transporte de mezclas asfalticas para distancias mayores de 1000m | 127d | 2017-11-23 | 2018-03-29 | 68SS | 203d |  | 3,478,003.3 |
| 70 | 1.6 | **800 Señalización y seguridad vial** | 142d | 2018-05-25 | 2018-10-13 |  | 5d |  | 8,830,378.92 |
| 71 | 1.6.1 | señal preventiva 0.75mx0.75m | 33d | 2018-08-05 | 2018-09-06 | 23 | 0d |  | 670,560.8 |
| 72 | 1.6.2 | señales reglamentarias rectangulares 1.20mx0.80m | 19d | 2018-09-07 | 2018-09-25 | 71 | 0d |  | 86,399.04 |
| 73 | 1.6.3 | señal reglamentaria octogonal 0.75mx0.75m | 2d | 2018-09-26 | 2018-09-27 | 72 | 0d |  | 5,149.89 |
| 74 | 1.6.4 | señal informativa de servicio 0.60mx2.00m | 3d | 2018-09-28 | 2018-09-30 | 73 | 0d |  | 38,198.49 |
| 75 | 1.6.5 | señales informativas 1.20mx2.40m | 13d | 2018-10-01 | 2018-10-13 | 74 | 5d |  | 154,610.56 |
| 76 | 1.6.6 | postes delineadores | 40d | 2018-08-15 | 2018-09-23 | 80 | 25d |  | 777,553.92 |
| 77 | 1.6.7 | poste de kilometraje | 24d | 2018-08-05 | 2018-08-28 | 23 | 51d |  | 18,596.8 |
| 78 | 1.6.8 | tachas retroreflectivas | 49d | 2018-08-05 | 2018-09-22 | 23 | 26d |  | 336,042.36 |
| 79 | 1.6.9 | marcas en el pavimento | 20d | 2018-08-05 | 2018-08-24 | 23, 24, 25, 26, 27 | 55d |  | 293,999.02 |
| 80 | 1.6.10 | guardavia metalica | 82d | 2018-05-25 | 2018-08-14 | 23FF+10d | 25d | 0d | 6,449,268.04 |
| 81 | 1.7 | **900 Impacto ambiental** | 880d | 2016-05-22 | 2018-10-18 |  | 0d |  | 7,363,380.06 |
| 82 | 1.7.1 | **sub programa de señalizacion ambiental** | 837d | 2016-07-04 | 2018-10-18 |  | 0d |  | 512,047.8 |
| 83 | 1.7.1.1 | señalizacion ambiental temporal | 20d | 2016-07-04 | 2016-07-23 | 4 | 26d | 0d | 35,058 |
| 84 | 1.7.1.2 | señalizacion informativa ambiental (permanente) | 10d | 2018-10-09 | 2018-10-18 | 74SS+11d | 0d |  | 29,982.6 |
| 85 | 1.7.1.3 | estructura de soporte de señales | 24d | 2018-09-25 | 2018-10-18 | 84FF | 0d |  | 447,007.2 |
| 86 | 1.7.2 | **programa de monitoreo ambiental** | 791d | 2016-07-24 | 2018-09-22 |  | 26d |  | 2,231,000 |
| 87 | 1.7.2.1 | monitoreo de calidad del agua | 16d | 2016-07-24 | 2018-09-20 | 83 | 28d |  | 400,000 |
| 88 | 1.7.2.2 | monitoreo de calidad del aire | 14d | 2016-07-24 | 2018-09-19 | 83 | 29d |  | 420,000 |
| 89 | 1.7.2.3 | monitoreo de control de niveles sonoros | 14d | 2016-07-24 | 2018-09-19 | 83 | 29d |  | 91,000 |
| 90 | 1.7.2.4 | monitoreo biologico | 22d | 2016-07-24 | 2018-09-22 | 83 | 26d |  | 1,100,000 |
| 91 | 1.7.2.5 | monitoreo calidad de suelos | 8d | 2016-07-24 | 2018-09-18 | 83 | 30d |  | 220,000 |

| ID | WBS | Task | Duration | Start | Finish | Predecessors | Total slack | Free slack | Cost |
| --- | --- | --- | --- | --- | --- | --- | --- | --- | --- |
| 92 | 1.7.3 | **programa de cierre de obras** | 844d | 2016-05-22 | 2018-09-12 |  | 36d |  | 4,620,332.26 |
| 93 | 1.7.3.1 | conformacion de material excedente en dme | 800d | 2016-05-22 | 2018-07-30 | 9SS+10d | 36d | 0d | 3,698,385.84 |
| 94 | 1.7.3.2 | restauracion de areas de canteras | 40d | 2018-07-31 | 2018-09-08 | 93 | 36d | 0d | 902,525.99 |
| 95 | 1.7.3.3 | restauracion de areas campamento y patio de maquinas | 4d | 2018-09-09 | 2018-09-12 | 94 | 36d |  | 19,420.43 |
| 96 | 1.8 | **1000 Puentes construccion** | 540d | 2016-07-04 | 2017-12-25 |  | 297d |  | 8,465,006.66 |
| 97 | 1.8.1 | **Puente Jahuay Chico** | 141d | 2016-07-04 | 2016-11-21 |  | 297d |  | 555,528.28 |
| 98 | 1.8.1.1 | **obras preliminares** | 1d | 2016-07-04 | 2016-07-04 |  | 297d |  | 673.98 |
| 99 | 1.8.1.1.1 | trazo y replanteo de puentes | 1d | 2016-07-04 | 2016-07-04 | 4 | 297d | 0d | 673.98 |
| 100 | 1.8.1.2 | **movimiento de tierras** | 89d | 2016-07-05 | 2016-10-01 |  | 297d |  | 49,228.4 |
| 101 | 1.8.1.2.1 | excavacion no clasificada para estructuras en seco | 2d | 2016-07-05 | 2016-07-06 | 99 | 297d | 0d | 3,948.41 |
| 102 | 1.8.1.2.2 | excavacion no clasificada para estructuras bajo agua | 3d | 2016-07-07 | 2016-07-09 | 101 | 297d | 0d | 8,492.44 |
| 103 | 1.8.1.2.3 | relleno para estructuras | 9d | 2016-09-23 | 2016-10-01 | 110FS+28d, 141 | 654d | 0d | 36,787.55 |
| 104 | 1.8.1.3 | **estribos (cimentacion)** | 12d | 2016-07-10 | 2016-07-21 |  | 297d |  | 67,851.01 |
| 105 | 1.8.1.3.1 | concreto clase h (f'c = 100 kg/cm2) | 1d | 2016-07-10 | 2016-07-10 | 102 | 297d | 0d | 3,126.7 |
| 106 | 1.8.1.3.2 | concreto clase c (f´c = 280 kg/cm2 ) | 6d | 2016-07-16 | 2016-07-21 | 107, 108FS-5d | 297d | 0d | 39,801.88 |
| 107 | 1.8.1.3.3 | encofrado y desencofrado | 5d | 2016-07-11 | 2016-07-15 | 105 | 297d | 0d | 3,427.54 |
| 108 | 1.8.1.3.4 | acero de refuerzo fy=4200 kg/cm2 | 10d | 2016-07-11 | 2016-07-20 | 107FS-5d | 297d | 0d | 21,494.89 |
| 109 | 1.8.1.4 | **estribos (elevacion)** | 35d | 2016-07-22 | 2016-08-25 |  | 297d |  | 129,992.34 |
| 110 | 1.8.1.4.1 | concreto clase d (f'c = 210kg/cm2) | 7d | 2016-08-19 | 2016-08-25 | 112, 113FS-5d | 297d | 0d | 44,654.4 |
| 111 | 1.8.1.4.2 | encofrado y desencofrado caravista | 16d | 2016-07-22 | 2016-08-06 | 106 | 297d | 0d | 14,071.62 |
| 112 | 1.8.1.4.3 | encofrado y desencofrado cara no vista | 11d | 2016-08-07 | 2016-08-17 | 111 | 298d | 1d | 8,164.06 |
| 113 | 1.8.1.4.4 | acero de refuerzo fy=4200 kg/cm2 | 29d | 2016-07-26 | 2016-08-23 | 111FS-12d | 297d | 0d | 63,102.26 |
| 114 | 1.8.1.5 | **superestructura** | 39d | 2016-09-01 | 2016-10-09 |  | 643d |  | 109,721.21 |
| 115 | 1.8.1.5.1 | **losa de concreto armado** | 19d | 2016-09-21 | 2016-10-09 |  | 643d |  | 33,582.32 |
| 116 | 1.8.1.5.1.1 | concreto clase c (f´c = 280 kg/cm2 ) | 2d | 2016-10-08 | 2016-10-09 | 124, 118, 145 | 643d | 0d | 13,814.37 |
| 117 | 1.8.1.5.1.2 | encofrado y desencofrado caravista | 12d | 2016-09-21 | 2016-10-02 | 125 | 643d | 0d | 9,985.23 |
| 118 | 1.8.1.5.1.3 | acero de refuerzo fy=4200 kg/cm2 | 9d | 2016-09-25 | 2016-10-03 | 126, 117FS-8d | 643d | 0d | 9,782.72 |

| ID | WBS | Task | Duration | Start | Finish | Predecessors | Total slack | Free slack | Cost |
| --- | --- | --- | --- | --- | --- | --- | --- | --- | --- |
| 119 | 1.8.1.5.2 | **vigas principales** | 36d | 2016-09-01 | 2016-10-06 |  | 643d |  | 67,154.37 |
| 120 | 1.8.1.5.2.1 | concreto clase c (f´c = 280 kg/cm2 ) | 3d | 2016-10-04 | 2016-10-06 | 122, 118 | 643d | 0d | 16,464.9 |
| 121 | 1.8.1.5.2.2 | encofrado y desencofrado caravista | 16d | 2016-09-01 | 2016-09-16 | 152, 110, 148 | 643d | 0d | 13,482.55 |
| 122 | 1.8.1.5.2.3 | acero de refuerzo fy=4200 kg/cm2 | 17d | 2016-09-05 | 2016-09-21 | 121FS-12d | 643d | 0d | 37,206.92 |
| 123 | 1.8.1.5.3 | **vigas diafragma** | 21d | 2016-09-17 | 2016-10-07 |  | 643d |  | 8,984.52 |
| 124 | 1.8.1.5.3.1 | concreto clase c (f´c = 280 kg/cm2 ) | 1d | 2016-10-07 | 2016-10-07 | 126, 120 | 643d | 0d | 2,461.84 |
| 125 | 1.8.1.5.3.2 | encofrado y desencofrado caravista | 4d | 2016-09-17 | 2016-09-20 | 121 | 643d | 0d | 3,239.14 |
| 126 | 1.8.1.5.3.3 | acero de refuerzo fy=4200 kg/cm2 | 3d | 2016-09-22 | 2016-09-24 | 122, 125 | 643d | 0d | 3,283.54 |
| 127 | 1.8.1.6 | **losa de aproximacion** | 15d | 2016-10-02 | 2016-10-16 |  | 643d |  | 9,547.41 |
| 128 | 1.8.1.6.1 | concreto clase h (f'c = 100 kg/cm2) | 1d | 2016-10-02 | 2016-10-02 | 103 | 654d | 11d | 729.02 |
| 129 | 1.8.1.6.2 | concreto clase c (f´c = 280 kg/cm2 ) | 1d | 2016-10-16 | 2016-10-16 | 131 | 643d | 0d | 7,324.07 |
| 130 | 1.8.1.6.3 | encofrado y desencofrado | 1d | 2016-10-14 | 2016-10-14 | 128, 144 | 643d | 0d | 491.6 |
| 131 | 1.8.1.6.4 | acero de refuerzo fy=4200 kg/cm2 | 1d | 2016-10-15 | 2016-10-15 | 130 | 643d | 0d | 1,002.72 |
| 132 | 1.8.1.7 | **veredas de concreto armado** | 8d | 2016-10-03 | 2016-10-10 |  | 660d |  | 4,681.42 |
| 133 | 1.8.1.7.1 | concreto clase c (f´c = 280 kg/cm2 ) | 1d | 2016-10-10 | 2016-10-10 | 135, 116, 146 | 660d | 0d | 2,672.47 |
| 134 | 1.8.1.7.2 | encofrado y desencofrado caravista | 1d | 2016-10-03 | 2016-10-03 | 117 | 664d | 0d | 689.23 |
| 135 | 1.8.1.7.3 | acero de refuerzo fy=4200 kg/cm2 | 2d | 2016-10-04 | 2016-10-05 | 134 | 664d | 4d | 1,319.72 |
| 136 | 1.8.1.8 | **pavimentos** | 2d | 2016-11-14 | 2016-11-15 |  | 643d |  | 92,912.81 |
| 137 | 1.8.1.8.1 | riego de liga | 1d | 2016-11-14 | 2016-11-14 | 129FS+28d | 643d | 0d | 331.79 |
| 138 | 1.8.1.8.2 | carpeta asfaltica en caliente e=5.00 cm | 1d | 2016-11-15 | 2016-11-15 | 137 | 643d | 0d | 92,581.02 |
| 139 | 1.8.1.9 | **transporte** | 15d | 2016-09-18 | 2016-10-02 |  | 655d |  | 10,436.33 |
| 140 | 1.8.1.9.1 | transporte de materiales granulares para distancias entre 120m y 1000m | 2d | 2016-09-18 | 2016-09-19 | 110FS+23d | 655d | 0d | 3,490.64 |
| 141 | 1.8.1.9.2 | transporte de materiales granulares para distancias mayores de 1000m | 2d | 2016-09-20 | 2016-09-21 | 140 | 655d | 1d | 751.35 |
| 142 | 1.8.1.9.3 | transporte de materiales excedentes para distancias entre 120 m y 1000 m | 1d | 2016-10-02 | 2016-10-02 | 102, 103 | 687d | 44d | 6,194.34 |

| ID | WBS | Task | Duration | Start | Finish | Predecessors | Total slack | Free slack | Cost |
| --- | --- | --- | --- | --- | --- | --- | --- | --- | --- |
| 143 | 1.8.1.10 | **varios** | 93d | 2016-08-21 | 2016-11-21 |  | 643d |  | 80,483.37 |
| 144 | 1.8.1.10.1 | junta de dilatacion | 4d | 2016-10-10 | 2016-10-13 | 116 | 643d | 0d | 5,536.96 |
| 145 | 1.8.1.10.2 | tubos de pvc sap d=4" | 1d | 2016-10-03 | 2016-10-03 | 117 | 647d | 4d | 222.34 |
| 146 | 1.8.1.10.3 | tubo de pvc sap clase 10, d=6" | 2d | 2016-10-04 | 2016-10-05 | 134 | 664d | 4d | 3,470.62 |
| 147 | 1.8.1.10.4 | apoyos de neopreno reforzado e=90 mm | 2d | 2016-08-26 | 2016-08-27 | 110 | 643d | 0d | 4,983.2 |
| 148 | 1.8.1.10.5 | perno de anclaje 1 1/4" | 1d | 2016-08-31 | 2016-08-31 | 151 | 643d | 0d | 233.12 |
| 149 | 1.8.1.10.6 | topes laterales | 1d | 2016-08-28 | 2016-08-28 | 147 | 643d | 0d | 600 |
| 150 | 1.8.1.10.7 | barandas metalicas | 4d | 2016-10-26 | 2016-10-29 | 133FS+15d | 660d | 17d | 28,441.42 |
| 151 | 1.8.1.10.8 | geocompuesto de drenaje tridimensional | 2d | 2016-08-29 | 2016-08-30 | 149 | 643d | 0d | 4,294.34 |
| 152 | 1.8.1.10.9 | falso puente | 9d | 2016-08-21 | 2016-08-29 | 110FS-5d | 645d | 2d | 26,206.01 |
| 153 | 1.8.1.10.10 | bruña rompe agua | 2d | 2016-11-02 | 2016-11-03 | 155 | 655d | 12d | 377.01 |
| 154 | 1.8.1.10.11 | impermeabilizacion con pintura bituminosa | 6d | 2016-11-16 | 2016-11-21 | 153, 150, 142, 138 | 643d | 65d | 4,209.63 |
| 155 | 1.8.1.10.12 | acabado borde de vigas | 5d | 2016-10-28 | 2016-11-01 | 120FS+21d | 655d | 0d | 1,908.72 |
| 156 | 1.8.2 | **Puente Pachas** | 165d | 2016-08-26 | 2017-02-06 |  | 297d |  | 1,120,026.44 |
| 157 | 1.8.2.1 | **obras preliminares** | 1d | 2016-08-26 | 2016-08-26 |  | 297d |  | 1,002.51 |
| 158 | 1.8.2.1.1 | trazo y replanteo de puentes | 1d | 2016-08-26 | 2016-08-26 | 110 | 297d | 0d | 1,002.51 |
| 159 | 1.8.2.2 | **movimiento de tierras** | 120d | 2016-08-27 | 2016-12-24 |  | 297d |  | 144,119.56 |
| 160 | 1.8.2.2.1 | excavacion no clasificada para estructuras en seco | 4d | 2016-08-27 | 2016-08-30 | 158 | 297d | 0d | 9,286.88 |
| 161 | 1.8.2.2.2 | excavacion no clasificada para estructuras bajo agua | 6d | 2016-08-31 | 2016-09-05 | 160 | 297d | 0d | 19,975.07 |
| 162 | 1.8.2.2.3 | relleno para estructuras | 14d | 2016-12-11 | 2016-12-24 | 201, 170FS+28d | 659d | 0d | 114,857.61 |
| 163 | 1.8.2.3 | **estribos (cimentacion)** | 21d | 2016-09-06 | 2016-09-26 |  | 297d |  | 182,270.73 |
| 164 | 1.8.2.3.1 | concreto clase h (f'c = 100 kg/cm2) | 1d | 2016-09-06 | 2016-09-06 | 161 | 297d | 0d | 5,530.85 |
| 165 | 1.8.2.3.2 | concreto clase f f'c = 140 kg/cm2 | 2d | 2016-09-18 | 2016-09-19 | 168FS-8d | 297d | 0d | 7,088 |
| 166 | 1.8.2.3.3 | concreto clase c (f´c = 280 kg/cm2 ) | 7d | 2016-09-20 | 2016-09-26 | 165 | 297d | 0d | 96,919.99 |
| 167 | 1.8.2.3.4 | encofrado y desencofrado | 8d | 2016-09-07 | 2016-09-14 | 164 | 297d | 0d | 6,096.04 |
| 168 | 1.8.2.3.5 | acero de refuerzo fy=4200 kg/cm2 | 16d | 2016-09-10 | 2016-09-25 | 167FS-5d | 297d | 0d | 66,635.85 |

| ID | WBS | Task | Duration | Start | Finish | Predecessors | Total slack | Free slack | Cost |
| --- | --- | --- | --- | --- | --- | --- | --- | --- | --- |
| 169 | 1.8.2.4 | **estribos (elevacion)** | 41d | 2016-09-27 | 2016-11-06 |  | 297d |  | 296,784.47 |
| 170 | 1.8.2.4.1 | concreto clase d (f'c = 210kg/cm2) | 9d | 2016-10-29 | 2016-11-06 | 173FS-7d | 297d | 0d | 115,032.92 |
| 171 | 1.8.2.4.2 | encofrado y desencofrado caravista | 16d | 2016-09-27 | 2016-10-12 | 166 | 297d | 0d | 26,959.9 |
| 172 | 1.8.2.4.3 | encofrado y desencofrado cara no vista | 11d | 2016-10-13 | 2016-10-23 | 171 | 297d | 0d | 17,091.09 |
| 173 | 1.8.2.4.4 | acero de refuerzo fy=4200 kg/cm2 | 32d | 2016-10-04 | 2016-11-04 | 172FS-20d | 297d | 0d | 137,700.56 |
| 174 | 1.8.2.5 | **superestructura** | 39d | 2016-11-17 | 2016-12-25 |  | 578d |  | 171,335.23 |
| 175 | 1.8.2.5.1 | **losa de concreto armado** | 22d | 2016-12-04 | 2016-12-25 |  | 578d |  | 62,902.05 |
| 176 | 1.8.2.5.1.1 | concreto clase c (f´c = 280 kg/cm2 ) | 3d | 2016-12-23 | 2016-12-25 | 184, 178, 206 | 578d | 0d | 22,836.71 |
| 177 | 1.8.2.5.1.2 | encofrado y desencofrado cara no vista | 15d | 2016-12-04 | 2016-12-18 | 185 | 578d | 0d | 11,476.87 |
| 178 | 1.8.2.5.1.3 | acero de refuerzo fy=4200 kg/cm2 | 14d | 2016-12-09 | 2016-12-22 | 177FS-10d | 578d | 0d | 28,588.47 |
| 179 | 1.8.2.5.2 | **vigas principales** | 26d | 2016-11-17 | 2016-12-12 |  | 578d |  | 91,099.68 |
| 180 | 1.8.2.5.2.1 | concreto clase c (f´c = 280 kg/cm2 ) | 4d | 2016-12-09 | 2016-12-12 | 182 | 587d | 0d | 28,295.76 |
| 181 | 1.8.2.5.2.2 | encofrado y desencofrado caravista | 13d | 2016-11-17 | 2016-11-29 | 209, 213 | 578d | 0d | 22,530.02 |
| 182 | 1.8.2.5.2.3 | acero de refuerzo fy=4200 kg/cm2 | 19d | 2016-11-20 | 2016-12-08 | 181FS-10d | 587d | 0d | 40,273.9 |
| 183 | 1.8.2.5.3 | **vigas diafragma** | 14d | 2016-11-30 | 2016-12-13 |  | 578d |  | 17,333.5 |
| 184 | 1.8.2.5.3.1 | concreto clase c (f´c = 280 kg/cm2 ) | 1d | 2016-12-13 | 2016-12-13 | 180, 186 | 587d | 9d | 5,033.38 |
| 185 | 1.8.2.5.3.2 | encofrado y desencofrado cara no vista | 4d | 2016-11-30 | 2016-12-03 | 181 | 578d | 0d | 4,740.32 |
| 186 | 1.8.2.5.3.3 | acero de refuerzo fy=4200 kg/cm2 | 4d | 2016-12-04 | 2016-12-07 | 185 | 592d | 5d | 7,559.8 |
| 187 | 1.8.2.6 | **losa de aproximacion** | 8d | 2016-12-28 | 2017-01-04 |  | 596d |  | 21,461.71 |
| 188 | 1.8.2.6.1 | concreto clase h (f'c = 100 kg/cm2) | 1d | 2016-12-28 | 2016-12-28 | 205 | 596d | 0d | 751.7 |
| 189 | 1.8.2.6.2 | concreto clase c (f´c = 280 kg/cm2 ) | 2d | 2017-01-03 | 2017-01-04 | 191FS-2d | 596d | 18d | 8,030.59 |
| 190 | 1.8.2.6.3 | encofrado y desencofrado | 1d | 2016-12-29 | 2016-12-29 | 188 | 596d | 0d | 715.75 |
| 191 | 1.8.2.6.4 | acero de refuerzo fy=4200 kg/cm2 | 6d | 2016-12-30 | 2017-01-04 | 190 | 596d | 0d | 11,963.67 |
| 192 | 1.8.2.7 | **veredas de concreto armado** | 4d | 2016-12-19 | 2016-12-22 |  | 592d |  | 5,245.35 |
| 193 | 1.8.2.7.1 | concreto clase c (f´c = 280 kg/cm2 ) | 1d | 2016-12-22 | 2016-12-22 | 195, 207 | 592d | 0d | 3,137.63 |
| 194 | 1.8.2.7.2 | encofrado y desencofrado cara no vista | 1d | 2016-12-19 | 2016-12-19 | 177 | 592d | 0d | 564.55 |
| 195 | 1.8.2.7.3 | acero de refuerzo fy=4200 kg/cm2 | 2d | 2016-12-20 | 2016-12-21 | 194 | 592d | 0d | 1,543.17 |

| ID | WBS | Task | Duration | Start | Finish | Predecessors | Total slack | Free slack | Cost |
| --- | --- | --- | --- | --- | --- | --- | --- | --- | --- |
| 196 | 1.8.2.8 | **pavimentos** | 3d | 2017-01-23 | 2017-01-25 |  | 578d |  | 132,609.38 |
| 197 | 1.8.2.8.1 | riego de liga | 1d | 2017-01-23 | 2017-01-23 | 176FS+28d, 189 | 578d | 0d | 473.55 |
| 198 | 1.8.2.8.2 | carpeta asfaltica en caliente e=5.00 cm | 2d | 2017-01-24 | 2017-01-25 | 197 | 578d | 0d | 132,135.83 |
| 199 | 1.8.2.9 | **transporte** | 24d | 2016-12-05 | 2016-12-28 |  | 659d |  | 64,694.72 |
| 200 | 1.8.2.9.1 | transporte de materiales granulares para distancias entre 120m y 1000m | 3d | 2016-12-05 | 2016-12-07 | 170FS+28d | 659d | 0d | 6,294.72 |
| 201 | 1.8.2.9.2 | transporte de materiales granulares para distancias mayores de 1000m | 3d | 2016-12-08 | 2016-12-10 | 200 | 659d | 0d | 672.05 |
| 202 | 1.8.2.9.3 | transporte de materiales excedentes para distancias entre 120 m y 1000 m | 2d | 2016-12-25 | 2016-12-26 | 162 | 659d | 0d | 16,726.07 |
| 203 | 1.8.2.9.4 | transporte de materiales excedentes para distancias mayores de 1000m | 2d | 2016-12-27 | 2016-12-28 | 202 | 659d |  | 41,001.88 |
| 204 | 1.8.2.10 | **varios** | 92d | 2016-11-07 | 2017-02-06 |  | 578d |  | 100,502.78 |
| 205 | 1.8.2.10.1 | junta de dilatacion | 5d | 2016-12-23 | 2016-12-27 | 193 | 596d | 0d | 7,424.56 |
| 206 | 1.8.2.10.2 | tubos de pvc sap d=4" | 1d | 2016-12-19 | 2016-12-19 | 177 | 581d | 0d | 129.7 |
| 207 | 1.8.2.10.3 | tubo de pvc sap clase 10, d=6" | 2d | 2016-12-20 | 2016-12-21 | 206 | 592d | 0d | 4,078.46 |
| 208 | 1.8.2.10.4 | apoyos de neopreno reforzado e=90 mm | 2d | 2016-11-07 | 2016-11-08 | 170 | 582d | 0d | 6,229 |
| 209 | 1.8.2.10.5 | perno de anclaje 1 1/4" | 1d | 2016-11-12 | 2016-11-12 | 212 | 582d | 4d | 145.7 |
| 210 | 1.8.2.10.6 | topes laterales | 1d | 2016-11-09 | 2016-11-09 | 208 | 582d | 0d | 600 |
| 211 | 1.8.2.10.7 | barandas metalicas | 5d | 2017-01-07 | 2017-01-11 | 193FS+15d | 592d | 14d | 33,422.69 |
| 212 | 1.8.2.10.8 | geocompuesto de drenaje tridimensional | 2d | 2016-11-10 | 2016-11-11 | 210 | 582d | 0d | 4,921.22 |
| 213 | 1.8.2.10.9 | falso puente | 10d | 2016-11-07 | 2016-11-16 | 170 | 578d | 0d | 30,830.6 |
| 214 | 1.8.2.10.10 | bruña rompe agua | 2d | 2017-01-04 | 2017-01-05 | 216 | 598d | 20d | 443.04 |
| 215 | 1.8.2.10.11 | impermeabilizacion con pintura bituminosa | 12d | 2017-01-26 | 2017-02-06 | 198, 211, 214, 154 | 578d | 43d | 9,479.8 |
| 216 | 1.8.2.10.12 | acabado borde de vigas | 7d | 2016-12-28 | 2017-01-03 | 180FS+15d | 598d | 0d | 2,798.01 |
| 217 | 1.8.3 | **Puente Chorro II** | 149d | 2017-06-28 | 2017-11-23 |  | 297d |  | 2,073,550.12 |
| 218 | 1.8.3.1 | **obras preliminares** | 1d | 2017-06-28 | 2017-06-28 |  | 297d |  | 1,300.87 |
| 219 | 1.8.3.1.1 | trazo y replanteo de puentes | 1d | 2017-06-28 | 2017-06-28 | 447 | 297d | 0d | 1,300.87 |

| ID | WBS | Task | Duration | Start | Finish | Predecessors | Total slack | Free slack | Cost |
| --- | --- | --- | --- | --- | --- | --- | --- | --- | --- |
| 220 | 1.8.3.2 | **movimiento de tierras** | 79d | 2017-06-29 | 2017-09-15 |  | 297d |  | 37,034.54 |
| 221 | 1.8.3.2.1 | excavacion no clasificada para estructuras en seco | 2d | 2017-06-29 | 2017-06-30 | 219 | 297d | 0d | 3,509.26 |
| 222 | 1.8.3.2.2 | excavacion no clasificada para estructuras bajo agua | 2d | 2017-07-01 | 2017-07-02 | 221 | 297d | 0d | 7,547.88 |
| 223 | 1.8.3.2.3 | relleno para estructuras | 4d | 2017-09-12 | 2017-09-15 | 257FS+24d | 381d | 0d | 25,977.4 |
| 224 | 1.8.3.3 | **estribos (cimentacion)** | 14d | 2017-07-03 | 2017-07-16 |  | 297d |  | 63,345.47 |
| 225 | 1.8.3.3.1 | concreto clase h (f'c = 100 kg/cm2) | 1d | 2017-07-03 | 2017-07-03 | 222 | 297d | 0d | 2,721.68 |
| 226 | 1.8.3.3.2 | concreto clase c (f´c = 280 kg/cm2 ) | 5d | 2017-07-12 | 2017-07-16 | 228FS-2d | 297d | 0d | 38,779.41 |
| 227 | 1.8.3.3.3 | encofrado y desencofrado | 5d | 2017-07-04 | 2017-07-08 | 225 | 297d | 0d | 3,728.78 |
| 228 | 1.8.3.3.4 | acero de refuerzo fy=4200 kg/cm2 | 9d | 2017-07-05 | 2017-07-13 | 227FS-4d | 297d | 0d | 18,115.6 |
| 229 | 1.8.3.4 | **estribos (elevacion)** | 29d | 2017-07-17 | 2017-08-14 |  | 297d |  | 81,316.65 |
| 230 | 1.8.3.4.1 | concreto clase d (f'c = 210kg/cm2) | 5d | 2017-08-10 | 2017-08-14 | 233FS-3d | 297d | 0d | 30,879.32 |
| 231 | 1.8.3.4.2 | encofrado y desencofrado caravista | 13d | 2017-07-17 | 2017-07-29 | 226 | 297d | 0d | 10,930.41 |
| 232 | 1.8.3.4.3 | encofrado y desencofrado cara no vista | 9d | 2017-07-30 | 2017-08-07 | 231 | 297d | 0d | 6,859.46 |
| 233 | 1.8.3.4.4 | acero de refuerzo fy=4200 kg/cm2 | 15d | 2017-07-29 | 2017-08-12 | 232FS-10d | 297d | 0d | 32,647.46 |
| 234 | 1.8.3.5 | **losa de concreto armado** | 27d | 2017-09-20 | 2017-10-16 |  | 323d |  | 95,488.51 |
| 235 | 1.8.3.5.1 | concreto clase c (f´c = 280 kg/cm2 ) | 4d | 2017-10-13 | 2017-10-16 | 237, 262 | 323d | 0d | 31,056 |
| 236 | 1.8.3.5.2 | encofrado y desencofrado caravista | 13d | 2017-09-20 | 2017-10-02 | 242 | 323d | 0d | 22,702.14 |
| 237 | 1.8.3.5.3 | acero de refuerzo fy=4200 kg/cm2 | 20d | 2017-09-23 | 2017-10-12 | 236FS-10d | 323d | 0d | 41,730.37 |
| 238 | 1.8.3.6 | **vigas metalicas** | 84d | 2017-06-29 | 2017-09-20 |  | 342d |  | 1,497,630.58 |
| 239 | 1.8.3.6.1 | fabricacion de vigas metalicas | 23d | 2017-06-29 | 2017-07-21 | 219 | 342d | 0d | 900,985.19 |
| 240 | 1.8.3.6.2 | pintura de estructura metalica | 1d | 2017-09-20 | 2017-09-20 | 242 | 380d | 57d | 84,871.15 |
| 241 | 1.8.3.6.3 | transporte de estructura metalica | 10d | 2017-07-22 | 2017-07-31 | 239 | 342d | 19d | 95,296.56 |
| 242 | 1.8.3.6.4 | montaje y lanzamiento de estructura metálica | 31d | 2017-08-20 | 2017-09-19 | 241, 265 | 323d | 0d | 416,477.68 |
| 243 | 1.8.3.7 | **losa de aproximacion** | 7d | 2017-10-15 | 2017-10-21 |  | 346d |  | 15,532.67 |
| 244 | 1.8.3.7.1 | concreto clase h (f'c = 100 kg/cm2) | 1d | 2017-10-15 | 2017-10-15 | 261 | 346d | 0d | 541.1 |
| 245 | 1.8.3.7.2 | concreto clase c (f´c = 280 kg/cm2 ) | 1d | 2017-10-21 | 2017-10-21 | 247 | 346d | 23d | 6,073.41 |
| 246 | 1.8.3.7.3 | encofrado y desencofrado | 1d | 2017-10-16 | 2017-10-16 | 244 | 346d | 0d | 532.51 |
| 247 | 1.8.3.7.4 | acero de refuerzo fy=4200 kg/cm2 | 4d | 2017-10-17 | 2017-10-20 | 246 | 346d | 0d | 8,385.65 |

| ID | WBS | Task | Duration | Start | Finish | Predecessors | Total slack | Free slack | Cost |
| --- | --- | --- | --- | --- | --- | --- | --- | --- | --- |
| 248 | 1.8.3.8 | **veredas de concreto armado** | 8d | 2017-10-03 | 2017-10-10 |  | 337d |  | 12,043.44 |
| 249 | 1.8.3.8.1 | concreto clase c (f´c = 280 kg/cm2 ) | 1d | 2017-10-10 | 2017-10-10 | 251, 263 | 337d | 0d | 6,003.19 |
| 250 | 1.8.3.8.2 | encofrado y desencofrado caravista | 4d | 2017-10-03 | 2017-10-06 | 236 | 337d | 0d | 3,019.53 |
| 251 | 1.8.3.8.3 | acero de refuerzo fy=4200 kg/cm2 | 3d | 2017-10-07 | 2017-10-09 | 250 | 337d | 0d | 3,020.72 |
| 252 | 1.8.3.9 | **pavimentos** | 3d | 2017-11-14 | 2017-11-16 |  | 323d |  | 140,630.62 |
| 253 | 1.8.3.9.1 | riego de liga | 1d | 2017-11-14 | 2017-11-14 | 235FS+28d, 245 | 323d | 0d | 502.19 |
| 254 | 1.8.3.9.2 | carpeta asfaltica en caliente e=5.00 cm | 2d | 2017-11-15 | 2017-11-16 | 253 | 323d | 0d | 140,128.43 |
| 255 | 1.8.3.10 | **transporte** | 36d | 2017-08-15 | 2017-09-19 |  | 381d |  | 37,455.8 |
| 256 | 1.8.3.10.1 | transporte de materiales granulares para distancias entre 120m y 1000m | 2d | 2017-08-15 | 2017-08-16 | 230 | 381d | 0d | 3,490.64 |
| 257 | 1.8.3.10.2 | transporte de materiales granulares para distancias mayores de 1000m | 2d | 2017-08-17 | 2017-08-18 | 256 | 381d | 0d | 5,445.33 |
| 258 | 1.8.3.10.3 | transporte de materiales excedentes para distancias entre 120 m y 1000 m | 2d | 2017-09-16 | 2017-09-17 | 223 | 381d | 0d | 6,320.26 |
| 259 | 1.8.3.10.4 | transporte de materiales excedentes para distancias mayores de 1000m | 2d | 2017-09-18 | 2017-09-19 | 258 | 381d | 58d | 22,199.57 |
| 260 | 1.8.3.11 | **varios** | 101d | 2017-08-15 | 2017-11-23 |  | 323d |  | 91,770.97 |
| 261 | 1.8.3.11.1 | junta de dilatacion | 4d | 2017-10-11 | 2017-10-14 | 249 | 346d | 0d | 5,536.96 |
| 262 | 1.8.3.11.2 | tubos de pvc sap d=4" | 1d | 2017-10-03 | 2017-10-03 | 236 | 332d | 9d | 481.73 |
| 263 | 1.8.3.11.3 | tubo de pvc sap clase 10, d=6" | 3d | 2017-10-07 | 2017-10-09 | 250 | 337d | 0d | 7,803.98 |
| 264 | 1.8.3.11.4 | apoyos de neopreno para puentes e=105 mm | 2d | 2017-08-15 | 2017-08-16 | 230 | 323d | 0d | 4,056 |
| 265 | 1.8.3.11.5 | perno de anclaje de 1 3/8" | 1d | 2017-08-19 | 2017-08-19 | 267 | 323d | 0d | 354.24 |
| 266 | 1.8.3.11.6 | barandas metalicas | 8d | 2017-10-26 | 2017-11-02 | 249FS+15d | 337d | 14d | 63,953.03 |
| 267 | 1.8.3.11.7 | geocompuesto de drenaje tridimensional | 2d | 2017-08-17 | 2017-08-18 | 264 | 323d | 0d | 3,774.48 |
| 268 | 1.8.3.11.8 | bruña rompe agua | 3d | 2017-10-17 | 2017-10-19 | 235 | 351d | 28d | 847.74 |
| 269 | 1.8.3.11.9 | impermeabilizacion con pintura bituminosa | 7d | 2017-11-17 | 2017-11-23 | 254, 266, 268, 259, 240 | 323d | 26d | 4,962.81 |
| 270 | 1.8.4 | **Puente Moro Moro** | 151d | 2016-11-07 | 2017-04-06 |  | 297d |  | 970,429.95 |
| 271 | 1.8.4.1 | **obras preliminares** | 1d | 2016-11-07 | 2016-11-07 |  | 297d |  | 765.07 |
| 272 | 1.8.4.1.1 | trazo y replanteo de puentes | 1d | 2016-11-07 | 2016-11-07 | 170 | 297d | 0d | 765.07 |

| ID | WBS | Task | Duration | Start | Finish | Predecessors | Total slack | Free slack | Cost |
| --- | --- | --- | --- | --- | --- | --- | --- | --- | --- |
| 273 | 1.8.4.2 | **movimiento de tierras** | 121d | 2016-11-08 | 2017-03-08 |  | 297d |  | 138,692 |
| 274 | 1.8.4.2.1 | excavacion no clasificada para estructuras en seco | 3d | 2016-11-08 | 2016-11-10 | 272 | 297d | 0d | 6,668.02 |
| 275 | 1.8.4.2.2 | excavacion no clasificada para estructuras bajo agua | 4d | 2016-11-11 | 2016-11-14 | 274 | 297d | 0d | 14,342.18 |
| 276 | 1.8.4.2.3 | relleno para estructuras | 15d | 2017-02-22 | 2017-03-08 | 314, 283FS+28d | 545d | 0d | 117,681.8 |
| 277 | 1.8.4.3 | **estribos (cimentacion)** | 19d | 2016-11-15 | 2016-12-03 |  | 297d |  | 158,482.56 |
| 278 | 1.8.4.3.1 | concreto clase h (f'c = 100 kg/cm2) | 1d | 2016-11-15 | 2016-11-15 | 275 | 297d | 0d | 4,986.51 |
| 279 | 1.8.4.3.2 | concreto clase c (f´c = 280 kg/cm2 ) | 6d | 2016-11-28 | 2016-12-03 | 281FS-5d | 297d | 0d | 83,737.54 |
| 280 | 1.8.4.3.3 | encofrado y desencofrado | 7d | 2016-11-16 | 2016-11-22 | 278 | 297d | 0d | 5,431.88 |
| 281 | 1.8.4.3.4 | acero de refuerzo fy=4200 kg/cm2 | 15d | 2016-11-18 | 2016-12-02 | 280FS-5d | 297d | 0d | 64,326.63 |
| 282 | 1.8.4.4 | **estribos (elevacion)** | 52d | 2016-12-04 | 2017-01-24 |  | 297d |  | 332,365.86 |
| 283 | 1.8.4.4.1 | concreto clase d (f'c = 210kg/cm2) | 9d | 2017-01-16 | 2017-01-24 | 286FS-5d | 297d | 0d | 115,032.92 |
| 284 | 1.8.4.4.2 | encofrado y desencofrado caravista | 16d | 2016-12-04 | 2016-12-19 | 279 | 297d | 0d | 26,959.9 |
| 285 | 1.8.4.4.3 | encofrado y desencofrado cara no vista | 22d | 2016-12-20 | 2017-01-10 | 284 | 297d | 0d | 17,091.09 |
| 286 | 1.8.4.4.4 | acero de refuerzo fy=4200 kg/cm2 | 40d | 2016-12-12 | 2017-01-20 | 285FS-30d | 297d | 0d | 173,281.95 |
| 287 | 1.8.4.5 | **superestructura** | 18d | 2017-02-02 | 2017-02-19 |  | 535d |  | 89,111.36 |
| 288 | 1.8.4.5.1 | **losa de concreto armado** | 13d | 2017-02-07 | 2017-02-19 |  | 535d |  | 34,882.15 |
| 289 | 1.8.4.5.1.1 | concreto clase c (f´c = 280 kg/cm2 ) | 2d | 2017-02-18 | 2017-02-19 | 297, 291, 319 | 535d | 0d | 12,269.69 |
| 290 | 1.8.4.5.1.2 | encofrado y desencofrado caravista | 9d | 2017-02-07 | 2017-02-15 | 298 | 535d | 0d | 7,356.68 |
| 291 | 1.8.4.5.1.3 | acero de refuerzo fy=4200 kg/cm2 | 7d | 2017-02-11 | 2017-02-17 | 290FS-5d | 535d | 0d | 15,255.78 |
| 292 | 1.8.4.5.2 | **vigas principales** | 12d | 2017-02-02 | 2017-02-13 |  | 535d |  | 47,408.61 |
| 293 | 1.8.4.5.2.1 | concreto clase c (f´c = 280 kg/cm2 ) | 2d | 2017-02-12 | 2017-02-13 | 295 | 538d | 0d | 14,055.72 |
| 294 | 1.8.4.5.2.2 | encofrado y desencofrado caravista | 2d | 2017-02-02 | 2017-02-03 | 326, 322 | 535d | 0d | 1,170.72 |
| 295 | 1.8.4.5.2.3 | acero de refuerzo fy=4200 kg/cm2 | 8d | 2017-02-04 | 2017-02-11 | 294 | 538d | 0d | 32,182.17 |
| 296 | 1.8.4.5.3 | **vigas diafragma** | 11d | 2017-02-04 | 2017-02-14 |  | 535d |  | 6,820.6 |
| 297 | 1.8.4.5.3.1 | concreto clase c (f´c = 280 kg/cm2 ) | 1d | 2017-02-14 | 2017-02-14 | 293, 299 | 538d | 3d | 1,856.25 |
| 298 | 1.8.4.5.3.2 | encofrado y desencofrado caravista | 3d | 2017-02-04 | 2017-02-06 | 294 | 535d | 0d | 2,405.24 |
| 299 | 1.8.4.5.3.3 | acero de refuerzo fy=4200 kg/cm2 | 3d | 2017-02-07 | 2017-02-09 | 298 | 542d | 4d | 2,559.11 |

| ID | WBS | Task | Duration | Start | Finish | Predecessors | Total slack | Free slack | Cost |
| --- | --- | --- | --- | --- | --- | --- | --- | --- | --- |
| 300 | 1.8.4.6 | **losa de aproximacion** | 8d | 2017-02-25 | 2017-03-04 |  | 550d |  | 19,667.59 |
| 301 | 1.8.4.6.1 | concreto clase h (f'c = 100 kg/cm2) | 1d | 2017-02-25 | 2017-02-25 | 318 | 550d | 0d | 793.82 |
| 302 | 1.8.4.6.2 | concreto clase c (f´c = 280 kg/cm2 ) | 1d | 2017-03-04 | 2017-03-04 | 304 | 550d | 15d | 7,859.45 |
| 303 | 1.8.4.6.3 | encofrado y desencofrado | 1d | 2017-02-26 | 2017-02-26 | 301 | 550d | 0d | 527.18 |
| 304 | 1.8.4.6.4 | acero de refuerzo fy=4200 kg/cm2 | 5d | 2017-02-27 | 2017-03-03 | 303 | 550d | 0d | 10,487.14 |
| 305 | 1.8.4.7 | **veredas de concreto armado** | 5d | 2017-02-16 | 2017-02-20 |  | 545d |  | 4,781.22 |
| 306 | 1.8.4.7.1 | concreto clase c (f´c = 280 kg/cm2 ) | 1d | 2017-02-20 | 2017-02-20 | 308, 289, 320 | 545d | 0d | 2,369.68 |
| 307 | 1.8.4.7.2 | encofrado y desencofrado caravista | 2d | 2017-02-16 | 2017-02-17 | 290 | 545d | 0d | 1,231.55 |
| 308 | 1.8.4.7.3 | acero de refuerzo fy=4200 kg/cm2 | 2d | 2017-02-18 | 2017-02-19 | 307 | 545d | 0d | 1,179.99 |
| 309 | 1.8.4.8 | **pavimentos** | 2d | 2017-03-20 | 2017-03-21 |  | 535d |  | 75,900 |
| 310 | 1.8.4.8.1 | riego de liga | 1d | 2017-03-20 | 2017-03-20 | 289FS+28d, 302 | 535d | 0d | 271.04 |
| 311 | 1.8.4.8.2 | carpeta asfaltica en caliente e=5.00 cm | 1d | 2017-03-21 | 2017-03-21 | 310 | 535d | 0d | 75,628.96 |
| 312 | 1.8.4.9 | **transporte** | 28d | 2017-02-12 | 2017-03-11 |  | 545d |  | 60,994.12 |
| 313 | 1.8.4.9.1 | transporte de materiales granulares para distancias entre 120m y 1000m | 5d | 2017-02-12 | 2017-02-16 | 283FS+18d | 545d | 0d | 12,012.2 |
| 314 | 1.8.4.9.2 | transporte de materiales granulares para distancias mayores de 1000m | 5d | 2017-02-17 | 2017-02-21 | 313 | 545d | 0d | 12,602.69 |
| 315 | 1.8.4.9.3 | transporte de materiales excedentes para distancias entre 120 m y 1000 m | 1d | 2017-03-09 | 2017-03-09 | 276 | 545d | 0d | 12,009.41 |
| 316 | 1.8.4.9.4 | transporte de materiales excedentes para distancias mayores de 1000m | 2d | 2017-03-10 | 2017-03-11 | 315 | 545d | 10d | 24,369.82 |
| 317 | 1.8.4.10 | **varios** | 72d | 2017-01-25 | 2017-04-06 |  | 535d |  | 89,670.17 |
| 318 | 1.8.4.10.1 | junta de dilatacion | 4d | 2017-02-21 | 2017-02-24 | 306 | 550d | 0d | 5,536.96 |
| 319 | 1.8.4.10.2 | tubos de pvc sap d=4" | 1d | 2017-02-16 | 2017-02-16 | 290 | 536d | 1d | 1,852.8 |
| 320 | 1.8.4.10.3 | tubo de pvc sap clase 10, d=6" | 2d | 2017-02-18 | 2017-02-19 | 319, 307 | 545d | 0d | 3,078.46 |
| 321 | 1.8.4.10.4 | apoyos de neopreno reforzado e=90 mm | 2d | 2017-01-25 | 2017-01-26 | 283 | 535d | 0d | 4,983.2 |
| 322 | 1.8.4.10.5 | perno de anclaje 1 1/4" | 1d | 2017-02-01 | 2017-02-01 | 325 | 535d | 0d | 116.56 |
| 323 | 1.8.4.10.6 | topes laterales | 1d | 2017-01-27 | 2017-01-27 | 321 | 535d | 0d | 600 |
| 324 | 1.8.4.10.7 | barandas metalicas | 4d | 2017-03-08 | 2017-03-11 | 306FS+15d | 545d | 10d | 25,227.7 |
| 325 | 1.8.4.10.8 | geocompuesto de drenaje tridimensional | 4d | 2017-01-28 | 2017-01-31 | 323 | 535d | 0d | 10,404.86 |
| 326 | 1.8.4.10.9 | falso puente | 8d | 2017-01-25 | 2017-02-01 | 283 | 535d | 0d | 23,122.95 |
| 327 | 1.8.4.10.10 | bruña rompe agua | 1d | 2017-02-18 | 2017-02-18 | 329 | 566d | 31d | 334.41 |
| 328 | 1.8.4.10.11 | impermeabilizacion con pintura bituminosa | 16d | 2017-03-22 | 2017-04-06 | 311, 324, 327, 316, 215 | 535d | 44d | 12,705.99 |
| 329 | 1.8.4.10.12 | acabado borde de vigas | 4d | 2017-02-14 | 2017-02-17 | 293 | 566d | 0d | 1,706.28 |

| ID | WBS | Task | Duration | Start | Finish | Predecessors | Total slack | Free slack | Cost |
| --- | --- | --- | --- | --- | --- | --- | --- | --- | --- |
| 330 | 1.8.5 | **Ponton Tamaña** | 129d | 2017-01-25 | 2017-06-02 |  | 297d |  | 667,897.12 |
| 331 | 1.8.5.1 | **obras preliminares** | 1d | 2017-01-25 | 2017-01-25 |  | 297d |  | 536.65 |
| 332 | 1.8.5.1.1 | trazo y replanteo de puentes | 1d | 2017-01-25 | 2017-01-25 | 283 | 297d | 0d | 536.65 |
| 333 | 1.8.5.2 | **movimiento de tierras** | 102d | 2017-01-26 | 2017-05-07 |  | 297d |  | 121,945.64 |
| 334 | 1.8.5.2.1 | excavacion no clasificada para estructuras en seco | 4d | 2017-01-26 | 2017-01-29 | 332 | 297d | 0d | 7,867.3 |
| 335 | 1.8.5.2.2 | excavacion no clasificada para estructuras bajo agua | 5d | 2017-01-30 | 2017-02-03 | 334 | 297d | 0d | 16,921.54 |
| 336 | 1.8.5.2.3 | relleno para estructuras | 12d | 2017-04-26 | 2017-05-07 | 366FS+20d, 343FS+28d | 527d | 0d | 97,156.8 |
| 337 | 1.8.5.3 | **estribos (cimentacion)** | 19d | 2017-02-04 | 2017-02-22 |  | 297d |  | 124,879.6 |
| 338 | 1.8.5.3.1 | concreto clase h (f'c = 100 kg/cm2) | 1d | 2017-02-04 | 2017-02-04 | 335 | 297d | 0d | 4,562.06 |
| 339 | 1.8.5.3.2 | concreto clase c (f´c = 280 kg/cm2 ) | 8d | 2017-02-15 | 2017-02-22 | 341FS-5d | 297d | 0d | 58,741.78 |
| 340 | 1.8.5.3.3 | encofrado y desencofrado | 6d | 2017-02-05 | 2017-02-10 | 338 | 297d | 0d | 4,165.23 |
| 341 | 1.8.5.3.4 | acero de refuerzo fy=4200 kg/cm2 | 14d | 2017-02-06 | 2017-02-19 | 340FS-5d | 297d | 0d | 57,410.53 |
| 342 | 1.8.5.4 | **estribos (elevacion)** | 34d | 2017-02-23 | 2017-03-28 |  | 297d |  | 167,694.36 |
| 343 | 1.8.5.4.1 | concreto clase d (f'c = 210kg/cm2) | 8d | 2017-03-21 | 2017-03-28 | 346FS-5d | 297d | 0d | 109,132.16 |
| 344 | 1.8.5.4.2 | encofrado y desencofrado caravista | 16d | 2017-02-23 | 2017-03-10 | 339 | 297d | 0d | 28,098.72 |
| 345 | 1.8.5.4.3 | encofrado y desencofrado cara no vista | 11d | 2017-03-11 | 2017-03-21 | 344 | 297d | 0d | 15,782.84 |
| 346 | 1.8.5.4.4 | acero de refuerzo fy=4200 kg/cm2 | 14d | 2017-03-12 | 2017-03-25 | 345FS-10d | 297d | 0d | 14,680.64 |
| 347 | 1.8.5.5 | **superestructura** | 18d | 2017-04-03 | 2017-04-20 |  | 491d |  | 51,408.91 |
| 348 | 1.8.5.5.1 | **losa de concreto armado** | 18d | 2017-04-03 | 2017-04-20 |  | 491d |  | 51,408.91 |
| 349 | 1.8.5.5.1.1 | concreto clase c (f´c = 280 kg/cm2 ) | 3d | 2017-04-18 | 2017-04-20 | 351, 374, 371 | 491d | 0d | 17,654.13 |
| 350 | 1.8.5.5.1.2 | encofrado y desencofrado caravista | 9d | 2017-04-03 | 2017-04-11 | 377 | 491d | 0d | 7,316.62 |
| 351 | 1.8.5.5.1.3 | acero de refuerzo fy=4200 kg/cm2 | 13d | 2017-04-05 | 2017-04-17 | 350FS-7d | 491d | 0d | 26,438.16 |
| 352 | 1.8.5.6 | **losa de aproximacion** | 10d | 2017-04-19 | 2017-04-28 |  | 511d |  | 21,088.58 |
| 353 | 1.8.5.6.1 | concreto clase h (f'c = 100 kg/cm2) | 1d | 2017-04-19 | 2017-04-19 | 370 | 511d | 0d | 839.19 |
| 354 | 1.8.5.6.2 | concreto clase c (f´c = 280 kg/cm2 ) | 2d | 2017-04-27 | 2017-04-28 | 356 | 511d | 20d | 8,302.66 |
| 355 | 1.8.5.6.3 | encofrado y desencofrado | 1d | 2017-04-20 | 2017-04-20 | 353 | 511d | 0d | 556.83 |
| 356 | 1.8.5.6.4 | acero de refuerzo fy=4200 kg/cm2 | 6d | 2017-04-21 | 2017-04-26 | 355 | 511d | 0d | 11,389.9 |

| ID | WBS | Task | Duration | Start | Finish | Predecessors | Total slack | Free slack | Cost |
| --- | --- | --- | --- | --- | --- | --- | --- | --- | --- |
| 357 | 1.8.5.7 | **veredas de concreto armado** | 3d | 2017-04-12 | 2017-04-14 |  | 511d |  | 3,006.46 |
| 358 | 1.8.5.7.1 | concreto clase c (f´c = 280 kg/cm2 ) | 1d | 2017-04-14 | 2017-04-14 | 360, 372 | 511d | 0d | 1,399.87 |
| 359 | 1.8.5.7.2 | encofrado y desencofrado caravista | 1d | 2017-04-12 | 2017-04-12 | 350 | 511d | 0d | 780.48 |
| 360 | 1.8.5.7.3 | acero de refuerzo fy=4200 kg/cm2 | 1d | 2017-04-13 | 2017-04-13 | 359 | 511d | 0d | 826.11 |
| 361 | 1.8.5.8 | **pavimentos** | 2d | 2017-05-19 | 2017-05-20 |  | 491d |  | 56,278.13 |
| 362 | 1.8.5.8.1 | riego de liga | 1d | 2017-05-19 | 2017-05-19 | 349FS+28d, 354 | 491d | 0d | 200.97 |
| 363 | 1.8.5.8.2 | carpeta asfaltica en caliente e=5.00 cm | 1d | 2017-05-20 | 2017-05-20 | 362 | 491d | 0d | 56,077.16 |
| 364 | 1.8.5.9 | **transporte** | 42d | 2017-03-29 | 2017-05-09 |  | 527d |  | 64,066.1 |
| 365 | 1.8.5.9.1 | transporte de materiales granulares para distancias entre 120m y 1000m | 4d | 2017-03-29 | 2017-04-01 | 343 | 527d | 0d | 9,928.73 |
| 366 | 1.8.5.9.2 | transporte de materiales granulares para distancias mayores de 1000m | 4d | 2017-04-02 | 2017-04-05 | 365 | 527d | 0d | 38,074.32 |
| 367 | 1.8.5.9.3 | transporte de materiales excedentes para distancias entre 120 m y 1000 m | 1d | 2017-05-08 | 2017-05-08 | 336 | 527d | 0d | 14,169.3 |
| 368 | 1.8.5.9.4 | transporte de materiales excedentes para distancias mayores de 1000m | 1d | 2017-05-09 | 2017-05-09 | 367 | 527d |  | 1,893.75 |
| 369 | 1.8.5.10 | **varios** | 66d | 2017-03-29 | 2017-06-02 |  | 491d |  | 56,992.69 |
| 370 | 1.8.5.10.1 | junta de dilatacion | 4d | 2017-04-15 | 2017-04-18 | 358 | 511d | 0d | 5,889.31 |
| 371 | 1.8.5.10.2 | tubos de pvc sap d=4" | 1d | 2017-04-12 | 2017-04-12 | 350 | 496d | 5d | 157.49 |
| 372 | 1.8.5.10.3 | tubo de pvc sap clase 10, d=6" | 1d | 2017-04-13 | 2017-04-13 | 359 | 511d | 0d | 1,821.58 |
| 373 | 1.8.5.10.4 | apoyos de neopreno para puentes e=25 mm | 2d | 2017-03-29 | 2017-03-30 | 343 | 505d | 0d | 1,948.52 |
| 374 | 1.8.5.10.5 | perno de anclaje de 1 3/8" | 1d | 2017-04-03 | 2017-04-03 | 376 | 505d | 14d | 376.38 |
| 375 | 1.8.5.10.6 | barandas metalicas | 2d | 2017-05-06 | 2017-05-07 | 349FS+15d | 504d | 13d | 15,040.21 |
| 376 | 1.8.5.10.7 | geocompuesto de drenaje tridimensional | 3d | 2017-03-31 | 2017-04-02 | 373 | 505d | 0d | 7,803.49 |
| 377 | 1.8.5.10.8 | falso puente | 5d | 2017-03-29 | 2017-04-02 | 343 | 491d | 0d | 13,164.67 |
| 378 | 1.8.5.10.9 | bruña rompe agua | 1d | 2017-04-21 | 2017-04-21 | 349 | 520d | 29d | 199.37 |
| 379 | 1.8.5.10.10 | impermeabilizacion con pintura bituminosa | 13d | 2017-05-21 | 2017-06-02 | 363, 375, 378, 328 | 491d | 92d | 10,591.67 |
| 380 | 1.8.6 | **Puente Salado** | 133d | 2017-08-15 | 2017-12-25 |  | 297d |  | 1,435,309.72 |
| 381 | 1.8.6.1 | **obras preliminares** | 1d | 2017-08-15 | 2017-08-15 |  | 297d |  | 887.74 |
| 382 | 1.8.6.1.1 | trazo y replanteo de puentes | 1d | 2017-08-15 | 2017-08-15 | 230 | 297d | 0d | 887.74 |

| ID | WBS | Task | Duration | Start | Finish | Predecessors | Total slack | Free slack | Cost |
| --- | --- | --- | --- | --- | --- | --- | --- | --- | --- |
| 383 | 1.8.6.2 | **movimiento de tierras** | 97d | 2017-08-16 | 2017-11-20 |  | 297d |  | 93,041.54 |
| 384 | 1.8.6.2.1 | excavacion no clasificada para estructuras en seco | 3d | 2017-08-16 | 2017-08-18 | 382 | 297d | 0d | 6,673.85 |
| 385 | 1.8.6.2.2 | excavacion no clasificada para estructuras bajo agua | 4d | 2017-08-19 | 2017-08-22 | 384 | 297d | 0d | 14,354.57 |
| 386 | 1.8.6.2.3 | relleno para estructuras | 9d | 2017-11-12 | 2017-11-20 | 421FS+22d | 324d | 0d | 72,013.12 |
| 387 | 1.8.6.3 | **estribos (cimentacion)** | 18d | 2017-08-23 | 2017-09-09 |  | 297d |  | 140,024.07 |
| 388 | 1.8.6.3.1 | concreto clase h (f'c = 100 kg/cm2) | 1d | 2017-08-23 | 2017-08-23 | 385 | 297d | 0d | 5,323.48 |
| 389 | 1.8.6.3.2 | concreto clase c (f´c = 280 kg/cm2 ) | 7d | 2017-09-03 | 2017-09-09 | 391FS-3d | 297d | 0d | 109,650.45 |
| 390 | 1.8.6.3.3 | encofrado y desencofrado | 9d | 2017-08-24 | 2017-09-01 | 388 | 297d | 0d | 6,934.54 |
| 391 | 1.8.6.3.4 | acero de refuerzo fy=4200 kg/cm2 | 9d | 2017-08-28 | 2017-09-05 | 390FS-5d | 297d | 0d | 18,115.6 |
| 392 | 1.8.6.4 | **estribos (elevacion)** | 33d | 2017-09-10 | 2017-10-12 |  | 297d |  | 192,185.52 |
| 393 | 1.8.6.4.1 | concreto clase d (f'c = 210kg/cm2) | 6d | 2017-10-07 | 2017-10-12 | 396FS-5d | 297d | 0d | 79,265.55 |
| 394 | 1.8.6.4.2 | encofrado y desencofrado caravista | 12d | 2017-09-10 | 2017-09-21 | 389 | 297d | 0d | 20,651.53 |
| 395 | 1.8.6.4.3 | encofrado y desencofrado cara no vista | 16d | 2017-09-22 | 2017-10-07 | 394 | 297d | 0d | 12,312.23 |
| 396 | 1.8.6.4.4 | acero de refuerzo fy=4200 kg/cm2 | 19d | 2017-09-23 | 2017-10-11 | 395FS-15d | 297d | 0d | 79,956.21 |
| 397 | 1.8.6.5 | **superestructura** | 96d | 2017-08-16 | 2017-11-19 |  | 327d |  | 734,620.66 |
| 398 | 1.8.6.5.1 | **losa de concreto armado** | 18d | 2017-11-02 | 2017-11-19 |  | 297d |  | 62,131.73 |
| 399 | 1.8.6.5.1.1 | concreto clase c (f´c = 280 kg/cm2 ) | 3d | 2017-11-17 | 2017-11-19 | 401, 426 | 297d | 0d | 20,067.7 |
| 400 | 1.8.6.5.1.2 | encofrado y desencofrado caravista | 9d | 2017-11-02 | 2017-11-10 | 406 | 297d | 0d | 14,808.32 |
| 401 | 1.8.6.5.1.3 | acero de refuerzo fy=4200 kg/cm2 | 13d | 2017-11-04 | 2017-11-16 | 400FS-7d | 297d | 0d | 27,255.71 |
| 402 | 1.8.6.5.2 | **vigas metalicas** | 79d | 2017-08-16 | 2017-11-02 |  | 344d |  | 672,488.93 |
| 403 | 1.8.6.5.2.1 | fabricacion de vigas metalicas | 11d | 2017-08-16 | 2017-08-26 | 382 | 345d | 0d | 402,479.11 |
| 404 | 1.8.6.5.2.2 | pintura de estructura metalica | 1d | 2017-11-02 | 2017-11-02 | 406 | 344d | 47d | 41,012.34 |
| 405 | 1.8.6.5.2.3 | transporte de estructura metalica | 5d | 2017-08-27 | 2017-08-31 | 403 | 345d | 48d | 42,641.21 |
| 406 | 1.8.6.5.2.4 | montaje y lanzamiento de estructura metálica | 14d | 2017-10-19 | 2017-11-01 | 405, 393, 429 | 297d | 0d | 186,356.27 |

| ID | WBS | Task | Duration | Start | Finish | Predecessors | Total slack | Free slack | Cost |
| --- | --- | --- | --- | --- | --- | --- | --- | --- | --- |
| 407 | 1.8.6.6 | **losa de aproximacion** | 8d | 2017-11-21 | 2017-11-28 |  | 316d |  | 19,666.48 |
| 408 | 1.8.6.6.1 | concreto clase h (f'c = 100 kg/cm2) | 1d | 2017-11-21 | 2017-11-21 | 425 | 316d | 0d | 793.82 |
| 409 | 1.8.6.6.2 | concreto clase c (f´c = 280 kg/cm2 ) | 1d | 2017-11-28 | 2017-11-28 | 411 | 316d | 19d | 7,859.45 |
| 410 | 1.8.6.6.3 | encofrado y desencofrado | 1d | 2017-11-22 | 2017-11-22 | 408 | 316d | 0d | 534.89 |
| 411 | 1.8.6.6.4 | acero de refuerzo fy=4200 kg/cm2 | 5d | 2017-11-23 | 2017-11-27 | 410 | 316d | 0d | 10,478.32 |
| 412 | 1.8.6.7 | **veredas de concreto armado** | 6d | 2017-11-11 | 2017-11-16 |  | 309d |  | 6,856.47 |
| 413 | 1.8.6.7.1 | concreto clase c (f´c = 280 kg/cm2 ) | 1d | 2017-11-16 | 2017-11-16 | 415, 427 | 309d | 0d | 3,892.42 |
| 414 | 1.8.6.7.2 | encofrado y desencofrado caravista | 3d | 2017-11-11 | 2017-11-13 | 400 | 309d | 0d | 1,980.87 |
| 415 | 1.8.6.7.3 | acero de refuerzo fy=4200 kg/cm2 | 1d | 2017-11-14 | 2017-11-14 | 414 | 310d | 1d | 983.18 |
| 416 | 1.8.6.8 | **pavimentos** | 2d | 2017-12-18 | 2017-12-19 |  | 297d |  | 106,087.5 |
| 417 | 1.8.6.8.1 | riego de liga | 1d | 2017-12-18 | 2017-12-18 | 399FS+28d, 409 | 297d | 0d | 378.84 |
| 418 | 1.8.6.8.2 | carpeta asfaltica en caliente e=5.00 cm | 1d | 2017-12-19 | 2017-12-19 | 417 | 297d | 0d | 105,708.66 |
| 419 | 1.8.6.9 | **transporte** | 41d | 2017-10-13 | 2017-11-22 |  | 324d |  | 73,948.09 |
| 420 | 1.8.6.9.1 | transporte de materiales granulares para distancias entre 120m y 1000m | 4d | 2017-10-13 | 2017-10-16 | 393 | 324d | 0d | 8,405.92 |
| 421 | 1.8.6.9.2 | transporte de materiales granulares para distancias mayores de 1000m | 4d | 2017-10-17 | 2017-10-20 | 420 | 324d | 0d | 49,984.04 |
| 422 | 1.8.6.9.3 | transporte de materiales excedentes para distancias entre 120 m y 1000 m | 1d | 2017-11-21 | 2017-11-21 | 386 | 324d | 0d | 12,019.93 |
| 423 | 1.8.6.9.4 | transporte de materiales excedentes para distancias mayores de 1000m | 1d | 2017-11-22 | 2017-11-22 | 422 | 324d | 27d | 3,538.2 |
| 424 | 1.8.6.10 | **varios** | 74d | 2017-10-13 | 2017-12-25 |  | 297d |  | 67,991.65 |
| 425 | 1.8.6.10.1 | junta de dilatacion | 4d | 2017-11-17 | 2017-11-20 | 413 | 316d | 0d | 5,536.96 |
| 426 | 1.8.6.10.2 | tubos de pvc sap d=4" | 1d | 2017-11-11 | 2017-11-11 | 400 | 302d | 5d | 296.45 |
| 427 | 1.8.6.10.3 | tubo de pvc sap clase 10, d=6" | 2d | 2017-11-14 | 2017-11-15 | 414 | 309d | 0d | 5,058.86 |
| 428 | 1.8.6.10.4 | apoyos de neopreno para puentes e=105 mm | 2d | 2017-10-13 | 2017-10-14 | 393 | 297d | 0d | 4,056 |
| 429 | 1.8.6.10.5 | perno de anclaje de 1 3/8" | 1d | 2017-10-18 | 2017-10-18 | 431 | 297d | 0d | 354.24 |
| 430 | 1.8.6.10.6 | barandas metalicas | 6d | 2017-12-02 | 2017-12-07 | 413FS+15d | 309d | 12d | 41,456.99 |
| 431 | 1.8.6.10.7 | geocompuesto de drenaje tridimensional | 3d | 2017-10-15 | 2017-10-17 | 428 | 297d | 0d | 6,472.98 |
| 432 | 1.8.6.10.8 | bruña rompe agua | 2d | 2017-11-20 | 2017-11-21 | 399 | 325d | 28d | 549.54 |
| 433 | 1.8.6.10.9 | impermeabilizacion con pintura bituminosa | 6d | 2017-12-20 | 2017-12-25 | 418, 430, 432, 423, 269, 404, 492 | 297d |  | 4,209.63 |

| ID | WBS | Task | Duration | Start | Finish | Predecessors | Total slack | Free slack | Cost |
| --- | --- | --- | --- | --- | --- | --- | --- | --- | --- |
| 434 | 1.8.7 | **Puente Amarillo** | 164d | 2017-03-29 | 2017-09-08 |  | 297d |  | 1,642,265.03 |
| 435 | 1.8.7.1 | **obras preliminares** | 1d | 2017-03-29 | 2017-03-29 |  | 297d |  | 966.13 |
| 436 | 1.8.7.1.1 | trazo y replanteo de puentes | 1d | 2017-03-29 | 2017-03-29 | 343 | 297d | 0d | 966.13 |
| 437 | 1.8.7.2 | **movimiento de tierras** | 138d | 2017-03-30 | 2017-08-14 |  | 297d |  | 203,470.75 |
| 438 | 1.8.7.2.1 | excavacion no clasificada para estructuras en seco | 5d | 2017-03-30 | 2017-04-03 | 436 | 297d | 0d | 12,583.56 |
| 439 | 1.8.7.2.2 | excavacion no clasificada para estructuras bajo agua | 7d | 2017-04-04 | 2017-04-10 | 438 | 297d | 0d | 27,065.88 |
| 440 | 1.8.7.2.3 | relleno para estructuras | 20d | 2017-07-26 | 2017-08-14 | 447FS+28d, 478 | 414d | 0d | 163,821.31 |
| 441 | 1.8.7.3 | **estribos (cimentacion)** | 31d | 2017-04-11 | 2017-05-11 |  | 297d |  | 221,563.73 |
| 442 | 1.8.7.3.1 | concreto clase h (f'c = 100 kg/cm2) | 2d | 2017-04-11 | 2017-04-12 | 439 | 297d | 0d | 6,593.6 |
| 443 | 1.8.7.3.2 | concreto clase c (f´c = 280 kg/cm2 ) | 13d | 2017-04-29 | 2017-05-11 | 445FS-10d | 297d | 0d | 102,716.94 |
| 444 | 1.8.7.3.3 | encofrado y desencofrado | 8d | 2017-04-13 | 2017-04-20 | 442 | 297d | 0d | 6,084.77 |
| 445 | 1.8.7.3.4 | acero de refuerzo fy=4200 kg/cm2 | 25d | 2017-04-14 | 2017-05-08 | 444FS-7d | 297d | 0d | 106,168.42 |
| 446 | 1.8.7.4 | **estribos (elevacion)** | 47d | 2017-05-12 | 2017-06-27 |  | 297d |  | 371,239.18 |
| 447 | 1.8.7.4.1 | concreto clase d (f'c = 210kg/cm2) | 10d | 2017-06-18 | 2017-06-27 | 450FS-9d | 297d | 0d | 139,445.33 |
| 448 | 1.8.7.4.2 | encofrado y desencofrado caravista | 21d | 2017-05-12 | 2017-06-01 | 443 | 297d | 0d | 35,956.93 |
| 449 | 1.8.7.4.3 | encofrado y desencofrado cara no vista | 15d | 2017-06-02 | 2017-06-16 | 448 | 297d | 0d | 22,620.43 |
| 450 | 1.8.7.4.4 | acero de refuerzo fy=4200 kg/cm2 | 40d | 2017-05-18 | 2017-06-26 | 449FS-30d | 297d | 0d | 173,216.49 |
| 451 | 1.8.7.5 | **superestructura** | 28d | 2017-07-06 | 2017-08-02 |  | 399d |  | 448,436.59 |
| 452 | 1.8.7.5.1 | **losa de concreto armado** | 22d | 2017-07-12 | 2017-08-02 |  | 399d |  | 52,724.72 |
| 453 | 1.8.7.5.1.1 | concreto clase c (f´c = 280 kg/cm2 ) | 3d | 2017-07-31 | 2017-08-02 | 455, 461, 483 | 399d | 0d | 18,378.2 |
| 454 | 1.8.7.5.1.2 | encofrado y desencofrado caravista | 7d | 2017-07-12 | 2017-07-18 | 462 | 405d | 0d | 11,489.06 |
| 455 | 1.8.7.5.1.3 | acero de refuerzo fy=4200 kg/cm2 | 11d | 2017-07-14 | 2017-07-24 | 454FS-5d | 405d | 6d | 22,857.46 |
| 456 | 1.8.7.5.2 | **vigas principales** | 14d | 2017-07-06 | 2017-07-19 |  | 399d |  | 62,082.67 |
| 457 | 1.8.7.5.2.1 | concreto clase c (f´c = 280 kg/cm2 ) | 3d | 2017-07-17 | 2017-07-19 | 459 | 399d | 0d | 18,689.77 |
| 458 | 1.8.7.5.2.2 | encofrado y desencofrado caravista | 1d | 2017-07-06 | 2017-07-06 | 486, 490 | 399d | 0d | 348.69 |
| 459 | 1.8.7.5.2.3 | acero de refuerzo fy=4200 kg/cm2 | 10d | 2017-07-07 | 2017-07-16 | 458 | 399d | 0d | 43,044.21 |

| ID | WBS | Task | Duration | Start | Finish | Predecessors | Total slack | Free slack | Cost |
| --- | --- | --- | --- | --- | --- | --- | --- | --- | --- |
| 460 | 1.8.7.5.3 | **vigas diafragma** | 24d | 2017-07-07 | 2017-07-30 |  | 399d |  | 333,629.2 |
| 461 | 1.8.7.5.3.1 | concreto clase c (f´c = 280 kg/cm2 ) | 11d | 2017-07-20 | 2017-07-30 | 457, 463 | 399d | 0d | 324,734.2 |
| 462 | 1.8.7.5.3.2 | encofrado y desencofrado caravista | 5d | 2017-07-07 | 2017-07-11 | 458 | 402d | 0d | 4,348.28 |
| 463 | 1.8.7.5.3.3 | acero de refuerzo fy=4200 kg/cm2 | 5d | 2017-07-12 | 2017-07-16 | 462 | 402d | 3d | 4,546.72 |
| 464 | 1.8.7.6 | **losa de aproximacion** | 9d | 2017-07-29 | 2017-08-06 |  | 423d |  | 27,248.39 |
| 465 | 1.8.7.6.1 | concreto clase h (f'c = 100 kg/cm2) | 1d | 2017-07-29 | 2017-07-29 | 482 | 423d | 0d | 1,134.04 |
| 466 | 1.8.7.6.2 | concreto clase c (f´c = 280 kg/cm2 ) | 2d | 2017-08-05 | 2017-08-06 | 468FS-2d | 423d | 24d | 10,689.9 |
| 467 | 1.8.7.6.3 | encofrado y desencofrado | 1d | 2017-07-30 | 2017-07-30 | 465 | 423d | 0d | 753.11 |
| 468 | 1.8.7.6.4 | acero de refuerzo fy=4200 kg/cm2 | 7d | 2017-07-31 | 2017-08-06 | 467 | 423d | 0d | 14,671.34 |
| 469 | 1.8.7.7 | **veredas de concreto armado** | 5d | 2017-07-19 | 2017-07-23 |  | 421d |  | 5,057.2 |
| 470 | 1.8.7.7.1 | concreto clase c (f´c = 280 kg/cm2 ) | 1d | 2017-07-23 | 2017-07-23 | 472, 484 | 421d | 0d | 2,518.88 |
| 471 | 1.8.7.7.2 | encofrado y desencofrado caravista | 2d | 2017-07-19 | 2017-07-20 | 454 | 421d | 0d | 1,263.46 |
| 472 | 1.8.7.7.3 | acero de refuerzo fy=4200 kg/cm2 | 2d | 2017-07-21 | 2017-07-22 | 471 | 421d | 0d | 1,274.86 |
| 473 | 1.8.7.8 | **pavimentos** | 3d | 2017-08-31 | 2017-09-02 |  | 399d |  | 111,521.25 |
| 474 | 1.8.7.8.1 | riego de liga | 1d | 2017-08-31 | 2017-08-31 | 466, 453FS+28d | 399d | 0d | 398.24 |
| 475 | 1.8.7.8.2 | carpeta asfaltica en caliente e=5.00 cm | 2d | 2017-09-01 | 2017-09-02 | 474 | 399d | 0d | 111,123.01 |
| 476 | 1.8.7.9 | **transporte** | 52d | 2017-06-28 | 2017-08-18 |  | 414d |  | 165,560.63 |
| 477 | 1.8.7.9.1 | transporte de materiales granulares para distancias entre 120m y 1000m | 7d | 2017-06-28 | 2017-07-04 | 447 | 428d | 0d | 16,217.26 |
| 478 | 1.8.7.9.2 | transporte de materiales granulares para distancias mayores de 1000m | 7d | 2017-07-05 | 2017-07-11 | 477 | 428d | 14d | 108,228.59 |
| 479 | 1.8.7.9.3 | transporte de materiales excedentes para distancias entre 120 m y 1000 m | 2d | 2017-08-15 | 2017-08-16 | 440 | 414d | 0d | 22,663.55 |
| 480 | 1.8.7.9.4 | transporte de materiales excedentes para distancias mayores de 1000m | 2d | 2017-08-17 | 2017-08-18 | 479 | 414d | 15d | 18,451.23 |
| 481 | 1.8.7.10 | **varios** | 73d | 2017-06-28 | 2017-09-08 |  | 399d |  | 87,201.18 |
| 482 | 1.8.7.10.1 | junta de dilatacion | 5d | 2017-07-24 | 2017-07-28 | 470 | 423d | 0d | 7,424.56 |
| 483 | 1.8.7.10.2 | tubos de pvc sap d=4" | 1d | 2017-07-19 | 2017-07-19 | 454 | 410d | 11d | 111.17 |
| 484 | 1.8.7.10.3 | tubo de pvc sap clase 10, d=6" | 2d | 2017-07-21 | 2017-07-22 | 471 | 421d | 0d | 3,274.54 |
| 485 | 1.8.7.10.4 | apoyos de neopreno reforzado e=90 mm | 2d | 2017-06-28 | 2017-06-29 | 447 | 399d | 0d | 6,229 |
| 486 | 1.8.7.10.5 | perno de anclaje 1 1/4" | 1d | 2017-07-05 | 2017-07-05 | 489 | 399d | 0d | 145.7 |
| 487 | 1.8.7.10.6 | topes laterales | 1d | 2017-06-30 | 2017-06-30 | 485 | 399d | 0d | 600 |
| 488 | 1.8.7.10.7 | barandas metalicas | 4d | 2017-08-08 | 2017-08-11 | 470FS+15d | 421d | 22d | 26,834.56 |
| 489 | 1.8.7.10.8 | geocompuesto de drenaje tridimensional | 4d | 2017-07-01 | 2017-07-04 | 487 | 399d | 0d | 11,558.79 |
| 490 | 1.8.7.10.9 | falso puente | 8d | 2017-06-28 | 2017-07-05 | 447 | 399d | 0d | 24,664.48 |
| 491 | 1.8.7.10.10 | bruña rompe agua | 1d | 2017-07-25 | 2017-07-25 | 493 | 438d | 39d | 355.71 |
| 492 | 1.8.7.10.11 | impermeabilizacion con pintura bituminosa | 6d | 2017-09-03 | 2017-09-08 | 475, 488, 491, 480, 379 | 399d | 102d | 4,209.63 |
| 493 | 1.8.7.10.12 | acabado borde de vigas | 5d | 2017-07-20 | 2017-07-24 | 457 | 438d | 0d | 1,793.04 |
